# Audit Project Plan_EMC

Schedule from MS Project, 2005-09-26 to 2007-05-03.
Draft Project Plan
TUT

## Calendars

- Standard: Mon-Fri 08:00-12:00, 13:00-17:00; Sat-Sun off.

## Resources

| Resource |
| --- |
| HEQC |
| EMC |
| DQP |
| 33 |

## Schedule

| ID | WBS | Task | Duration | Start | Finish | Total slack | Constraint |
| --- | --- | --- | --- | --- | --- | --- | --- |
| 1 | 1 | Announcement of HEQC Audit date | 1d | 2005-09-26 | 2005-09-26 | 415d | start no earlier than 2005-09-26 |
| 2 | 2 | EMC Declaration of Intent | 1d | 2005-10-10 | 2005-10-10 | 405d | start no earlier than 2005-10-10 |
| 3 | 3 | Constitute CAPC | 1d | 2005-11-01 | 2005-11-01 | 389d | start no earlier than 2005-11-01 |
| 4 | 4 | Communication | 402d | 2005-10-14 | 2007-04-30 | 3d | start no earlier than 2005-10-14 |
| 5 | 5 | **Workshop 1: Introduction** | 2d | 2005-11-21 | 2005-11-22 | 377d |  |
| 6 | 5.1 | Purpose, Process, Criteria | 2d | 2005-11-21 | 2005-11-22 | 374d | start no earlier than 2005-11-21 |
| 7 | 5.2 | Establish Working Groups (WG) | 2d | 2005-11-21 | 2005-11-22 | 374d | start no earlier than 2005-11-21 |
| 8 | 5.3 | WG Terms of Reference and reporting | 2d | 2005-11-21 | 2005-11-22 | 374d | start no earlier than 2005-11-21 |
| 9 | 6 | Road Shows | 20d | 2005-11-14 | 2005-12-09 | 361d | start no earlier than 2005-11-13 |
| 10 | 7 | **Workshop 2: Institutional Self Assessment** | 2d | 2006-01-23 | 2006-01-24 | 332d |  |
| 11 | 7.1 | Purpose, process, roles and responsibilties | 2d | 2006-01-23 | 2006-01-24 | 329d | start no earlier than 2006-01-23 |
| 12 | 7.2 | Indepth interrogation of criteria | 2d | 2006-01-23 | 2006-01-24 | 329d | start no earlier than 2006-01-23 |
| 13 | 7.3 | Data Sources | 2d | 2006-01-23 | 2006-01-24 | 329d | start no earlier than 2006-01-23 |
| 14 | 8 | CAPC Meeting | 1d? | 2006-02-02 | 2006-02-02 | 325d | start no earlier than 2006-02-02 |
| 15 | 9 | Senate Presentation | 1d? | 2006-03-23 | 2006-03-23 | 290d | start no earlier than 2006-03-23 |
| 16 | 10 | Council Presentation | 1d? | 2006-03-28 | 2006-03-28 | 287d | start no earlier than 2006-03-28 |
| 17 | 11 | Conduct Self Assessment | 35d | 2006-01-23 | 2006-03-10 | 299d | start no earlier than 2006-01-23 |
| 18 | 12 | Workshop 3: Mid Point Evaluation | 1d | 2006-02-17 | 2006-02-17 | 314d | start no earlier than 2006-02-17 |
| 19 | 13 | **Workshop 4** | 2d | 2006-03-16 | 2006-03-17 | 294d |  |
| 20 | 13.1 | Interrogation of reports | 2d | 2006-03-16 | 2006-03-17 | 294d | start no earlier than 2006-03-16 |
| 21 | 13.2 | Validation of evidence | 2d | 2006-03-16 | 2006-03-17 | 294d | start no earlier than 2006-03-16 |
| 22 | 14 | **Self Assessment Report: 1st Draft** | 20d | 2006-03-27 | 2006-04-21 | 269d |  |
| 23 | 14.1 | Construct the 1st draft SA report | 20d | 2006-03-27 | 2006-04-21 | 269d | start no earlier than 2006-03-27 |
| 24 | 14.2 | Portfolio of Evidence | 20d | 2006-03-27 | 2006-04-21 | 269d | start no earlier than 2006-03-27 |
| 25 | 15 | CAPC Meeting | 1d? | 2006-04-06 | 2006-04-06 | 280d | start no earlier than 2006-04-06 |
| 26 | 16 | Workshop 5: SA Report and PoE | 2d | 2006-04-27 | 2006-04-28 | 264d | start no earlier than 2006-04-27 |
| 27 | 17 | CAPC Meeting | 1d? | 2006-05-04 | 2006-05-04 | 260d | start no earlier than 2006-05-04 |
| 28 | 18 | Circulate for Comment | 2d | 2006-05-08 | 2006-05-09 | 257d | start no earlier than 2006-05-08 |
| 29 | 19 | CAPC Meeting | 1d? | 2006-06-01 | 2006-06-01 | 240d | start no earlier than 2006-06-01 |
| 30 | 20 | Road Shows | 20d | 2006-05-08 | 2006-06-02 | 239d | start no earlier than 2006-05-07 |
| 31 | 21 | Consolidate Comments | 5d | 2006-05-22 | 2006-05-26 | 244d | start no earlier than 2006-05-22 |

| ID | WBS | Task | Duration | Start | Finish | Total slack | Constraint |
| --- | --- | --- | --- | --- | --- | --- | --- |
| 32 | 22 | **Trial Audit** | 35d | 2006-05-08 | 2006-06-23 | 224d |  |
| 33 | 22.1 | Identify review panel | 5d | 2006-05-08 | 2006-05-12 | 254d | finish no earlier than 2006-05-12 |
| 34 | 22.2 | Circulate SA report for analysis | 5d | 2006-05-29 | 2006-06-02 | 239d | start no earlier than 2006-05-29 |
| 35 | 22.3 | Conduct trial audit | 5d | 2006-06-19 | 2006-06-23 | 224d | start no earlier than 2006-06-19 |
| 36 | 23 | CAPC Meeting | 1d? | 2006-07-06 | 2006-07-06 | 215d | start no earlier than 2006-07-06 |
| 37 | 24 | Workshop 6: Trial Audit Findings | 2d | 2006-07-27 | 2006-07-28 | 199d | start no earlier than 2006-07-27 |
| 38 | 25 | **Audit Portfolio (SAR, IP, PoE)** | 40d | 2006-07-31 | 2006-09-22 | 159d |  |
| 39 | 25.1 | Construct Audit Portfolio | 40d | 2006-07-31 | 2006-09-22 | 159d | start no earlier than 2006-07-31 |
| 40 | 26 | CAPC Meeting | 1d? | 2006-08-03 | 2006-08-03 | 195d | start no earlier than 2006-08-03 |
| 41 | 27 | CAPC Meeting | 1d? | 2006-09-07 | 2006-09-07 | 170d | start no earlier than 2006-09-07 |
| 42 | 28 | Workshop 7: SAR, IP, PoE alignment | 2d | 2006-09-28 | 2006-09-29 | 154d | start no earlier than 2006-09-28 |
| 43 | 29 | CAPC Meeting | 1d? | 2006-10-05 | 2006-10-05 | 150d | start no earlier than 2006-10-05 |
| 44 | 30 | Circulate for comment | 2d | 2006-10-02 | 2006-10-03 | 152d | start no earlier than 2006-10-02 |
| 45 | 31 | Road Shows | 20d | 2006-10-09 | 2006-11-03 | 129d | start no earlier than 2006-10-08 |
| 46 | 32 | **Audit Portfolio Final Draft** | 30d | 2006-10-09 | 2006-11-17 | 119d |  |
| 47 | 32.1 | Construct final draft | 30d | 2006-10-09 | 2006-11-17 | 119d | start no earlier than 2006-10-09 |
| 48 | 33 | CAPC Meeting | 1d? | 2006-11-02 | 2006-11-02 | 130d | start no earlier than 2006-11-02 |
| 49 | 34 | Workshop 8: Internal consistency of AP | 2d | 2006-11-23 | 2006-11-24 | 114d | start no earlier than 2006-11-23 |
| 50 | 35 | CAPC Meeting | 1d? | 2006-11-30 | 2006-11-30 | 110d | start no earlier than 2006-11-30 |
| 51 | 36 | Circulate for comment | 30d | 2006-12-11 | 2007-01-19 | 74d | start no earlier than 2006-12-11 |
| 52 | 37 | CAPC Meeting | 1d? | 2007-01-04 | 2007-01-04 | 85d | start no earlier than 2007-01-04 |
| 53 | 38 | Special Senate | 1d? | 2007-01-12 | 2007-01-12 | 79d | start no earlier than 2007-01-12 |
| 54 | 39 | Special Council | 1d? | 2007-01-26 | 2007-01-26 | 69d | start no earlier than 2007-01-26 |
| 55 | 40 | CAPC Meeting | 1d? | 2007-02-01 | 2007-02-01 | 65d | start no earlier than 2007-02-01 |

| ID | WBS | Task | Duration | Start | Finish | Total slack | Constraint |
| --- | --- | --- | --- | --- | --- | --- | --- |
| 56 | 41 | **Audit Portfolio** | 25d | 2007-02-05 | 2007-03-09 | 39d |  |
| 57 | 41.1 | Sumbmission to HEQC | 1d | 2007-02-05 | 2007-02-05 | 63d | start no earlier than 2007-02-05 |
| 58 | 41.2 | Workshop portfolio within TUT (staff and student) | 15d | 2007-02-19 | 2007-03-09 | 39d | finish no earlier than 2007-03-09 |
| 59 | 42 | CAPC Meeting | 1d? | 2007-03-01 | 2007-03-01 | 45d | start no earlier than 2007-03-01 |
| 60 | 43 | **Audit Visit** | 30d | 2007-03-12 | 2007-04-20 | 9d |  |
| 61 | 43.1 | Internal logistics | 30d | 2007-03-12 | 2007-04-20 | 9d | finish no earlier than 2007-04-20 |
| 62 | 43.2 | Workshop 8: Briefing critical groups | 10d | 2007-04-02 | 2007-04-13 | 14d | finish no earlier than 2007-04-13 |
| 63 | 43.3 | Audit Visit | 5d | 2007-04-16 | 2007-04-20 | 9d | start no earlier than 2007-04-16 |
| 64 | 44 | CAPC Meeting | 1d? | 2007-04-05 | 2007-04-05 | 20d | start no earlier than 2007-04-05 |
| 65 | 45 | Internal logistics | 30d | 2007-03-12 | 2007-04-20 | 9d | finish no earlier than 2007-04-20 |
| 66 | 46 | Workshop 8: Briefing critical groups | 10d | 2007-04-02 | 2007-04-13 | 14d | finish no earlier than 2007-04-13 |
| 67 | 47 | Audit Visit | 5d | 2007-04-16 | 2007-04-20 | 9d | start no earlier than 2007-04-16 |
| 68 | 48 | CAPC Meeting | 1d? | 2007-05-03 | 2007-05-03 | 0d | start no earlier than 2007-05-03 |
